# Wingtip Toys Commercial

Schedule from MS Project, 2005-01-03 to 2005-01-25, costs in $.

## Calendars

- Standard: Mon-Fri 08:00-12:00, 13:00-17:00; Sat-Sun off.

## Resources

| Resource | Unit | Rate | Notes |
| --- | --- | --- | --- |
| Garrett R. Vargas |  | 20 | Garrett attending West Coast film festival January 13 and 14; unavailable to work on project. |
| Jim Hance |  | 18.75 |  |
| Scott Cooper |  | 19.37 |  |
| Jo Brown |  | 18.75 |  |
| Patti Mintz |  | 9.4 |  |
| Peter Kelly |  | 16.75 |  |
| John Rodman |  | 22 |  |
| Jonathan Mollerup |  | 10 |  |
| Jon Ganio |  | 15.5 |  |
| Electrician |  | 22 |  |
| Mini-DV Camcorder |  | 6.25 |  |
| 600-Watt Light and Stand |  | 2.5 |  |
| Reflector Kit |  |  |  |
| Camera Boom |  |  |  |
| Editing Lab |  | 25 |  |
| Video Tape | 30-min. cassette | 5 |  |

## Schedule

| ID | WBS | Task | Type | Duration | Start | Finish | Predecessors | Total slack | Resources | Work | Cost |
| --- | --- | --- | --- | --- | --- | --- | --- | --- | --- | --- | --- |
| 1 | 1 | **Pre-Production** |  | 8.5d | 2005-01-03 | 2005-01-13 |  | 0d |  | 168h | 2,631.7 |
| 2 | 1.1 | Develop script |  | 2.5d | 2005-01-03 | 2005-01-05 |  | 0d | Garrett R. Vargas; Scott Cooper | 40h | 787.5 |
| 3 | 1.2 | Develop production boards |  | 3d | 2005-01-05 | 2005-01-10 | 2 | 0d | Garrett R. Vargas; Patti Mintz | 48h | 705.6 |
| 4 | 1.3 | Pick locations |  | 1d | 2005-01-10 | 2005-01-11 | 3 | 0d | Scott Cooper; Patti Mintz; Video Tape [4 30-min. cassette] | 16h | 250.2 |
| 5 | 1.4 | Hold auditions |  | 2d | 2005-01-11 | 2005-01-13 | 4 | 0d | Peter Kelly; Scott Cooper; Jonathan Mollerup; Patti Mintz | 64h | 888.4 |
| 6 | 1.5 | Pre-Production complete! | milestone | 0d | 2005-01-13 | 2005-01-13 | 5 | 0d |  |  |  |
| 7 | 2 | **Production** |  | 4.5d | 2005-01-13 | 2005-01-19 | 1 | 0d |  | 456h | 4,476.7 |
| 8 | 2.1 | Rehearse |  | 2.25d | 2005-01-13 | 2005-01-17 |  | 0d | Garrett R. Vargas; Jim Hance; Scott Cooper; Patti Mintz; Peter Kelly; Jon Ganio [50%]; John Rodman; 600-Watt Light and Stand [400%]; Camera Boom [200%]; Mini-DV Camcorder; Reflector Kit; Video Tape [1 30-min. cassette] | 214h | 1,717.4 |
| 9 | 2.2 | Shoot video |  | 2d | 2005-01-17 | 2005-01-18 | 8 | 0d | Garrett R. Vargas; Jim Hance; Scott Cooper; Patti Mintz; Peter Kelly; Jon Ganio [50%]; John Rodman; 600-Watt Light and Stand [400%]; Camera Boom [200%]; Mini-DV Camcorder [300%]; Reflector Kit; Video Tape [16 30-min. cassette]; Electrician [200%] | 226h | 2,409.3 |
| 10 | 2.3 | Log footage |  | 1d | 2005-01-19 | 2005-01-19 | 9 | 0d | Jo Brown; Editing Lab | 16h | 350 |
| 11 | 2.4 | Production complete! | milestone | 0d | 2005-01-19 | 2005-01-19 | 10 | 0d |  |  |  |
| 12 | 3 | **Post-Production** |  | 3.5d | 2005-01-20 | 2005-01-25 | 7 | 0d |  | 76h | 1,563 |
| 13 | 3.1 | Fine cut edit |  | 2d | 2005-01-20 | 2005-01-21 |  | 0d | Editing Lab; Scott Cooper; Peter Kelly | 48h | 978 |
| 14 | 3.2 | Add final audio |  | 1d | 2005-01-24 | 2005-01-24 | 13 | 0d | Editing Lab; Jo Brown; Scott Cooper | 24h | 505 |
| 15 | 3.3 | Hand off master to client |  | 4h | 2005-01-25 | 2005-01-25 | 14 | 0d | Garrett R. Vargas | 4h | 80 |

Notes:
- 4: Includes exterior street scene and indoor studio scenes.
